# New Product

Schedule from MS Project, 2000-01-03 to 2002-12-09.

## Calendars

- Standard: Mon-Fri 08:00-12:00, 13:00-17:00; Sat-Sun off.

## Resources

| Resource |
| --- |
| Management |
| Product Engineering |
| Legal |
| Marketing |
| Project Manager |
| Process Engineer |
| Manufacturing Engineer |
| Safety |
| Accounting |
| Customer |
| Purchasing |

## Schedule

| ID | WBS | Task | Type | Duration | Start | Finish | Predecessors | Total slack | Resources | Work |
| --- | --- | --- | --- | --- | --- | --- | --- | --- | --- | --- |
| 1 | 1 | **New Product Development Template** |  | 766d | 2000-01-03 | 2002-12-09 |  | 0d |  | 15688h |
| 2 | 1.1 | **Initial New Product Screening Stage** |  | 9d | 2000-01-03 | 2000-01-13 |  | 0d |  | 72h |
| 3 | 1.1.1 | New product opportunity identified | milestone | 0d | 2000-01-03 | 2000-01-03 |  | 0d | Management; Product Engineering |  |
| 4 | 1.1.2 | Describe new product idea (1-page written disclosure) |  | 2d | 2000-01-03 | 2000-01-04 | 3 | 0d | Product Engineering | 16h |
| 5 | 1.1.3 | Gather information required for go/no-go decision |  | 6d | 2000-01-05 | 2000-01-12 | 4 | 0d | Product Engineering | 48h |
| 6 | 1.1.4 | Convene opportunity of screening committee (decision to pursue idea or not) |  | 1d | 2000-01-13 | 2000-01-13 | 5 | 0d | Product Engineering | 8h |
| 7 | 1.1.5 | Decision point - go/no-go to preliminary investigation | milestone | 0d | 2000-01-13 | 2000-01-13 | 6 | 0d | Management; Product Engineering |  |
| 8 | 1.2 | **Preliminary Investigation Stage** |  | 53d | 2000-01-14 | 2000-03-28 |  | 0d |  | 1216h |
| 9 | 1.2.1 | Assign resources to preliminary investigation |  | 1d | 2000-01-14 | 2000-01-14 | 7 | 0d | Management | 8h |
| 10 | 1.2.2 | Develop preliminary investigation plan |  | 5d | 2000-01-17 | 2000-01-21 | 9 | 751d | Product Engineering; Project Manager | 80h |
| 11 | 1.2.3 | Evaluate the market |  | 10d | 2000-01-17 | 2000-01-28 | 9 | 746d | Marketing | 80h |
| 12 | 1.2.4 | Analyze the competition |  | 5d | 2000-01-17 | 2000-01-21 | 9 | 0d | Marketing | 40h |
| 13 | 1.2.5 | **Technical Feasibility Analysis** |  | 20d | 2000-01-24 | 2000-02-18 |  | 0d |  | 160h |
| 14 | 1.2.5.1 | Produce lab scale product |  | 10d | 2000-01-24 | 2000-02-04 | 12 | 0d | Product Engineering | 80h |
| 15 | 1.2.5.2 | Evaluate internal product |  | 5d | 2000-02-07 | 2000-02-11 | 14 | 0d | Product Engineering | 40h |
| 16 | 1.2.5.3 | Identify production process steps required for manufacture |  | 5d | 2000-02-14 | 2000-02-18 | 15 | 0d | Process Engineer | 40h |
| 17 | 1.2.6 | Assess manufacturing capabilities |  | 10d | 2000-02-21 | 2000-03-03 | 16 | 0d | Product Engineering; Manufacturing Engineer | 160h |
| 18 | 1.2.7 | Determine safety issues |  | 10d | 2000-02-21 | 2000-03-03 | 17SS | 0d | Safety | 80h |
| 19 | 1.2.8 | Determine environmental issues |  | 10d | 2000-02-21 | 2000-03-03 | 18SS | 0d | Product Engineering; Legal | 160h |
| 20 | 1.2.9 | Review legal issues |  | 10d | 2000-02-21 | 2000-03-03 | 19SS | 0d | Legal; Project Manager | 160h |
| 21 | 1.2.10 | Perform financial evaluation |  | 10d | 2000-03-06 | 2000-03-17 | 20, 17, 18, 19 | 0d | Accounting | 80h |
| 22 | 1.2.11 | Develop risk analysis |  | 5d | 2000-03-20 | 2000-03-24 | 21 | 0d | Product Engineering; Project Manager | 80h |
| 23 | 1.2.12 | Draft initial development stage plan |  | 10d | 2000-03-06 | 2000-03-17 | 21SS | 5d | Product Engineering | 80h |
| 24 | 1.2.13 | Conduct preliminary stage review decision |  | 2d | 2000-03-27 | 2000-03-28 | 22, 23 | 0d | Management; Product Engineering; Project Manager | 48h |
| 25 | 1.2.14 | Decision point - go/no-go to development stage | milestone | 0d | 2000-03-28 | 2000-03-28 | 24 | 704d | Management; Project Manager |  |

| ID | WBS | Task | Type | Duration | Start | Finish | Predecessors | Total slack | Free slack | Resources | Work |
| --- | --- | --- | --- | --- | --- | --- | --- | --- | --- | --- | --- |
| 26 | 1.3 | **Development Stage** |  | 264d | 2000-03-29 | 2001-04-02 |  | 0d |  |  | 5408h |
| 27 | 1.3.1 | Assign resources to development stage plan |  | 1d | 2000-03-29 | 2000-03-29 | 24 | 0d |  | Management; Project Manager | 16h |
| 28 | 1.3.2 | **Market Evaluation** |  | 40d | 2000-03-30 | 2000-05-24 |  | 2d |  |  | 480h |
| 29 | 1.3.2.1 | Gather market information |  | 15d | 2000-03-30 | 2000-04-19 | 27 | 2d | 0d | Product Engineering; Marketing | 240h |
| 30 | 1.3.2.2 | Identify and contact customer sample group |  | 5d | 2000-04-20 | 2000-04-26 | 29 | 12d | 10d | Marketing | 40h |
| 31 | 1.3.2.3 | Perform competitor analysis |  | 15d | 2000-04-20 | 2000-05-10 | 29 | 2d | 0d | Marketing | 120h |
| 32 | 1.3.2.4 | Redefine product requirements |  | 10d | 2000-05-11 | 2000-05-24 | 30, 31 | 2d |  | Product Engineering | 80h |
| 33 | 1.3.3 | **Technical Product Evaluation** |  | 204d | 2000-03-30 | 2001-01-09 |  | 0d |  |  | 3488h |
| 34 | 1.3.3.1 | Establish product characteristics (performance criteria) |  | 2d | 2000-03-30 | 2000-03-31 | 27 | 0d |  | Product Engineering | 16h |
| 35 | 1.3.3.2 | Develop prototype process |  | 10d | 2000-04-03 | 2000-04-14 | 34 | 0d |  | Product Engineering | 80h |
| 36 | 1.3.3.3 | Produce prototype product |  | 25d | 2000-04-17 | 2000-05-19 | 35 | 0d |  | Product Engineering | 200h |
| 37 | 1.3.3.4 | Conduct internal product review |  | 5d | 2000-05-22 | 2000-05-26 | 36 | 0d |  | Management; Product Engineering | 80h |
| 38 | 1.3.3.5 | Document patent application process |  | 10d | 2000-04-03 | 2000-04-14 | 34 | 229d | 194d | Product Engineering | 80h |
| 39 | 1.3.3.6 | Conduct marketing/technical review |  | 92d | 2000-05-29 | 2000-10-03 | 37, 32 | 0d |  | Marketing; Product Engineering | 1472h |
| 40 | 1.3.3.7 | Redesign process (if necessary) |  | 10d | 2000-10-04 | 2000-10-17 | 39 | 0d |  | Product Engineering; Process Engineer | 160h |
| 41 | 1.3.3.8 | Modify prototype process |  | 15d | 2000-10-18 | 2000-11-07 | 40 | 0d |  | Process Engineer | 120h |
| 42 | 1.3.3.9 | Develop plan for customer product testing |  | 5d | 2000-11-08 | 2000-11-14 | 41 | 20d |  | Project Manager | 40h |
| 43 | 1.3.3.10 | Produce product for customer evaluation |  | 25d | 2000-11-08 | 2000-12-12 | 41 | 0d |  | Product Engineering; Marketing; Project Manager | 600h |
| 44 | 1.3.3.11 | Conduct preliminary manufacturing process review |  | 10d | 2000-12-13 | 2000-12-26 | 43 | 10d |  | Process Engineer; Manufacturing Engineer | 160h |
| 45 | 1.3.3.12 | Conduct customer evaluations of prototype product |  | 20d | 2000-12-13 | 2001-01-09 | 43, 42 | 0d |  | Product Engineering; Project Manager; Customer | 480h |
| 46 | 1.3.4 | **Concept Evaluation** |  | 57d | 2001-01-10 | 2001-03-29 |  | 0d |  |  | 1376h |
| 47 | 1.3.4.1 | Conduct marketing/technical review |  | 2d | 2001-01-10 | 2001-01-11 | 45, 44 | 0d |  | Management; Product Engineering; Marketing | 48h |
| 48 | 1.3.4.2 | Prepare preliminary manufacturing design |  | 20d | 2001-01-12 | 2001-02-08 | 47 | 0d |  | Product Engineering | 160h |
| 49 | 1.3.4.3 | Evaluate contract manufacturing option |  | 10d | 2001-02-09 | 2001-02-22 | 48 | 467d |  | Legal; Process Engineer | 160h |
| 50 | 1.3.4.4 | Review legal and patent considerations |  | 10d | 2001-01-12 | 2001-01-25 | 47, 38 | 35d |  | Management; Legal | 160h |
| 51 | 1.3.4.5 | Perform environmental review |  | 10d | 2001-02-09 | 2001-02-22 | 48 | 5d |  | Product Engineering | 80h |
| 52 | 1.3.4.6 | Conduct product safety review |  | 15d | 2001-01-12 | 2001-02-01 | 47 | 20d |  | Product Engineering; Safety | 240h |
| 53 | 1.3.4.7 | Perform evaluate/predict product cycle time |  | 15d | 2001-02-09 | 2001-03-01 | 48 | 0d |  | Product Engineering; Project Manager | 240h |
| 54 | 1.3.4.8 | Update financial analysis |  | 10d | 2001-03-02 | 2001-03-15 | 53, 52, 51, 57 | 0d |  | Accounting | 80h |
| 55 | 1.3.4.9 | Risk analysis |  | 10d | 2001-03-16 | 2001-03-29 | 50, 54, 52 | 0d |  | Product Engineering | 80h |
| 56 | 1.3.4.10 | Review preliminary investigation criteria |  | 2d | 2001-03-16 | 2001-03-19 | 54 | 8d |  | Management; Product Engineering; Legal | 48h |
| 57 | 1.3.4.11 | Develop pilot stage plan |  | 5d | 2001-01-12 | 2001-01-18 | 48SS | 30d |  | Product Engineering; Project Manager | 80h |
| 58 | 1.3.5 | Conduct development stage review |  | 2d | 2001-03-30 | 2001-04-02 | 55, 56, 57 | 0d |  | Product Engineering; Project Manager; Process Engineer | 48h |
| 59 | 1.3.6 | Decision point - go/no-go to pilot stage | milestone | 0d | 2001-04-02 | 2001-04-02 | 58 | 0d |  | Management; Project Manager |  |

| ID | WBS | Task | Duration | Start | Finish | Predecessors | Total slack | Resources | Work |
| --- | --- | --- | --- | --- | --- | --- | --- | --- | --- |
| 60 | 1.4 | **Pilot Stage** | 115d | 2001-04-03 | 2001-09-10 |  | 0d |  | 1992h |
| 61 | 1.4.1 | Assign pilot stage resources | 1d | 2001-04-03 | 2001-04-03 | 58, 59 | 0d | Management; Project Manager | 16h |
| 62 | 1.4.2 | Secure customer commitment to participate in commercialization trials | 5d | 2001-04-04 | 2001-04-10 | 61 | 0d | Legal; Project Manager | 80h |
| 63 | 1.4.3 | **Trial Product Manufacture** | 70d | 2001-04-11 | 2001-07-17 |  | 0d |  | 1160h |
| 64 | 1.4.3.1 | Schedule/reserve pilot production facility | 5d | 2001-04-11 | 2001-04-17 | 62 | 0d | Project Manager | 40h |
| 65 | 1.4.3.2 | Resolve raw material and finish products logistics | 5d | 2001-04-18 | 2001-04-24 | 64 | 0d | Product Engineering; Project Manager | 80h |
| 66 | 1.4.3.3 | Review trial plan and requirements | 5d | 2001-04-11 | 2001-04-17 | 62 | 5d | Product Engineering; Project Manager | 80h |
| 67 | 1.4.3.4 | Start trial material production | 30d | 2001-04-25 | 2001-06-05 | 65, 66 | 0d | Product Engineering | 240h |
| 68 | 1.4.3.5 | Monitor customer trials | 20d | 2001-04-25 | 2001-05-22 | 67SS | 0d | Product Engineering | 160h |
| 69 | 1.4.3.6 | Review preliminary trial results | 10d | 2001-05-23 | 2001-06-05 | 68 | 0d | Product Engineering; Project Manager | 160h |
| 70 | 1.4.3.7 | Continue trial material production | 30d | 2001-06-06 | 2001-07-17 | 69 | 0d | Product Engineering | 240h |
| 71 | 1.4.3.8 | Complete customer trial monitoring | 20d | 2001-06-06 | 2001-07-03 | 70SS | 0d | Product Engineering | 160h |
| 72 | 1.4.4 | **Trial Analysis** | 49d | 2001-07-04 | 2001-09-10 |  | 0d |  | 736h |
| 73 | 1.4.4.1 | Confirm sales and marketing strategies | 5d | 2001-07-04 | 2001-07-10 | 71 | 0d | Marketing; Project Manager | 80h |
| 74 | 1.4.4.2 | Confirm product safety | 5d | 2001-07-04 | 2001-07-10 | 73SS | 0d | Project Manager; Safety | 80h |
| 75 | 1.4.4.3 | Re-evaluate manufacturing processes | 15d | 2001-07-11 | 2001-07-31 | 73, 74 | 0d | Process Engineer | 120h |
| 76 | 1.4.4.4 | Develop commercialization plan | 15d | 2001-08-01 | 2001-08-21 | 75 | 0d | Product Engineering; Marketing | 240h |
| 77 | 1.4.4.5 | Review financials | 5d | 2001-08-22 | 2001-08-28 | 76 | 5d | Accounting | 40h |
| 78 | 1.4.4.6 | Review patent and legal issues | 10d | 2001-08-22 | 2001-09-04 | 76 | 0d | Legal | 80h |
| 79 | 1.4.4.7 | Assign commercialization leadership responsibility and resources | 2d | 2001-09-05 | 2001-09-06 | 77, 78 | 0d | Management; Project Manager | 32h |
| 80 | 1.4.4.8 | Pilot stage review and commercialization decision | 2d | 2001-09-07 | 2001-09-10 | 79 | 0d | Management; Product Engineering; Marketing; Process Engineer | 64h |
| 81 | 1.5 | **Commercialization Stage** | 195d | 2001-09-11 | 2002-06-10 |  | 0d |  | 3480h |
| 82 | 1.5.1 | **Product Manufacturing and Monitoring** | 168d | 2001-09-11 | 2002-05-02 |  | 0d |  | 2608h |
| 83 | 1.5.1.1 | Confirm product specification | 3d | 2001-09-11 | 2001-09-13 | 80 | 0d | Product Engineering; Manufacturing Engineer | 48h |
| 84 | 1.5.1.2 | Confirm customer specification acceptance and trial participation | 10d | 2001-09-14 | 2001-09-27 | 83 | 0d | Product Engineering; Project Manager | 160h |
| 85 | 1.5.1.3 | Develop manufacturing process requirements | 10d | 2001-09-28 | 2001-10-11 | 84 | 0d | Process Engineer; Manufacturing Engineer | 160h |
| 86 | 1.5.1.4 | Design and order new equipment | 30d | 2001-10-12 | 2001-11-22 | 85 | 0d | Product Engineering; Purchasing | 480h |
| 87 | 1.5.1.5 | Install and test new equipment or equipment modifications | 30d | 2001-11-23 | 2002-01-03 | 86 | 0d | Product Engineering; Manufacturing Engineer | 480h |
| 88 | 1.5.1.6 | Confirm manufacturing capabilities | 10d | 2002-01-04 | 2002-01-17 | 87 | 0d | Manufacturing Engineer | 80h |
| 89 | 1.5.1.7 | Develop and review production trial plan (resolve logistics issues) | 5d | 2002-01-18 | 2002-01-24 | 88 | 0d | Product Engineering; Project Manager | 80h |
| 90 | 1.5.1.8 | Start production of commercial product quantities | 40d | 2002-01-25 | 2002-03-21 | 89 | 0d | Product Engineering; Manufacturing Engineer | 640h |
| 91 | 1.5.1.9 | Monitor customer acceptance testing | 30d | 2002-03-22 | 2002-05-02 | 90 | 0d | Product Engineering; Project Manager | 480h |

| ID | WBS | Task | Duration | Start | Finish | Predecessors | Total slack | Free slack | Resources | Work |
| --- | --- | --- | --- | --- | --- | --- | --- | --- | --- | --- |
| 92 | 1.5.2 | **Commercialization Analysis** | 57d | 2002-03-22 | 2002-06-10 |  | 0d |  |  | 872h |
| 93 | 1.5.2.1 | Perform internal product testing | 15d | 2002-03-22 | 2002-04-11 | 90 | 15d |  | Product Engineering | 120h |
| 94 | 1.5.2.2 | Review production performance results | 10d | 2002-05-03 | 2002-05-16 | 91, 93 | 0d |  | Management; Product Engineering; Project Manager | 240h |
| 95 | 1.5.2.3 | Identify long term production requirements | 15d | 2002-05-17 | 2002-06-06 | 94 | 0d |  | Process Engineer; Manufacturing Engineer | 240h |
| 96 | 1.5.2.4 | Recalculate product economics | 10d | 2002-05-17 | 2002-05-30 | 94 | 5d |  | Product Engineering; Marketing; Accounting | 240h |
| 97 | 1.5.2.5 | Affirm decision to continue commercialization program | 2d | 2002-06-07 | 2002-06-10 | 96, 95 | 0d |  | Management; Project Manager | 32h |
| 98 | 1.6 | **Post Commercialization Review** | 130d | 2002-06-11 | 2002-12-09 |  | 0d |  |  | 3520h |
| 99 | 1.6.1 | Determine if product is meeting customer cost/performance expectations | 60d | 2002-06-11 | 2002-09-02 | 97 | 0d |  | Management; Project Manager | 960h |
| 100 | 1.6.2 | Determine if sales have met projections | 60d | 2002-06-11 | 2002-09-02 | 99SS | 40d | 0d | Management; Marketing | 960h |
| 101 | 1.6.3 | Determine if product is sustaining its position against competitive response | 30d | 2002-09-03 | 2002-10-14 | 100 | 40d |  | Management; Marketing | 480h |
| 102 | 1.6.4 | Evaluate manufacturing process for stability and cost effectiveness | 40d | 2002-09-03 | 2002-10-28 | 99 | 0d |  | Project Manager; Manufacturing Engineer | 640h |
| 103 | 1.6.5 | Determine if current economics are consistent with projected economics | 15d | 2002-10-29 | 2002-11-18 | 102 | 0d |  | Marketing | 120h |
| 104 | 1.6.6 | Evaluate opportunities to expand product or product line | 15d | 2002-11-19 | 2002-12-09 | 103 | 0d |  | Management; Product Engineering; Marketing | 360h |
